| id | name | startDate | endDate | priority | barScale | progress | type | parentId | dependencies |
| --- | --- | --- | --- | --- | --- | --- | --- | --- | --- |
| 1 | Event Planning | 2026-06-01T00:00:00.000Z | 2026-08-10T00:00:00.000Z | medium | 1 | 0 | group |  |  |
| 2 | Define goals and success metrics | 2026-06-01T00:00:00.000Z | 2026-06-06T00:00:00.000Z | high | 1 | 0 | task | 1 |  |
| 3 | Set the event budget | 2026-06-04T00:00:00.000Z | 2026-06-11T00:00:00.000Z | medium | 1 | 0 | task | 1 |  |
| 4 | Shortlist and tour venues | 2026-06-06T00:00:00.000Z | 2026-06-15T00:00:00.000Z | medium | 1 | 0 | task | 1 | 2 FS |
| 5 | Book venue and confirm date | 2026-06-15T00:00:00.000Z | 2026-06-16T00:00:00.000Z | high | 1 | 0 | milestone | 1 | 4 FS |
| 6 | Book catering and finalize menu | 2026-06-16T00:00:00.000Z | 2026-06-28T00:00:00.000Z | medium | 1 | 0 | task | 1 | 5 FS |
| 7 | Book AV/production vendor | 2026-06-16T00:00:00.000Z | 2026-06-26T00:00:00.000Z | medium | 1 | 0 | task | 1 | 5 FS |
| 8 | Book rentals (furniture, tent, decor) | 2026-06-16T00:00:00.000Z | 2026-06-26T00:00:00.000Z | medium | 1 | 0 | task | 1 | 5 FS |
| 9 | Draft the run-of-show | 2026-06-21T00:00:00.000Z | 2026-07-01T00:00:00.000Z | medium | 1 | 0 | task | 1 | 5 FS |
| 10 | Launch registration and invitations | 2026-06-29T00:00:00.000Z | 2026-07-06T00:00:00.000Z | medium | 1 | 0 | task | 1 | 5 FS |
| 11 | Run marketing and promotion push | 2026-06-29T00:00:00.000Z | 2026-07-19T00:00:00.000Z | medium | 1 | 0 | task | 1 | 5 FS |
| 12 | Track RSVPs, meals, and access needs | 2026-07-06T00:00:00.000Z | 2026-07-26T00:00:00.000Z | medium | 1 | 0 | task | 1 | 10 FS |
| 13 | Recruit and confirm staff/volunteers | 2026-07-06T00:00:00.000Z | 2026-07-20T00:00:00.000Z | high | 1 | 0 | task | 1 |  |
| 14 | Finalize floor plan, signage, staging | 2026-07-13T00:00:00.000Z | 2026-07-27T00:00:00.000Z | medium | 1 | 0 | task | 1 | 8 FS |
| 15 | Brief staff and volunteers on roles | 2026-07-20T00:00:00.000Z | 2026-07-23T00:00:00.000Z | medium | 1 | 0 | task | 1 | 13 FS |
| 16 | Confirm final headcount with vendors | 2026-07-26T00:00:00.000Z | 2026-07-27T00:00:00.000Z | high | 1 | 0 | milestone | 1 | 12 FS |
| 17 | Final venue walkthrough | 2026-07-27T00:00:00.000Z | 2026-07-29T00:00:00.000Z | medium | 1 | 0 | task | 1 | 16 FS |
| 18 | Event day | 2026-08-03T00:00:00.000Z | 2026-08-04T00:00:00.000Z | high | 1 | 0 | milestone | 1 | 17 FS |
| 19 | Send thank-you notes | 2026-08-04T00:00:00.000Z | 2026-08-07T00:00:00.000Z | medium | 1 | 0 | task | 1 | 18 FS |
| 20 | Post-event debrief and wrap-up report | 2026-08-07T00:00:00.000Z | 2026-08-10T00:00:00.000Z | medium | 1 | 0 | task | 1 | 19 FS |
